# Organisation d'un colloque scientifique

How a schedule from MS Project changed from version to version. A marks actual dates.

## Version 1 (saved 2018-06-12, file Projet2.mpp)

| ID | Task | Duration | Start | Finish | Total float |
| --- | --- | --- | --- | --- | --- |
| 1 | Planification du colloque scientifique | 1d? | 2014-06-16 | 2014-06-16 | 0d |
| 2 | Réunions initiales de planification | 1d? | 2014-06-16 | 2014-06-16 | 0d |
| 3 | Définition du contenu des conférences | 1d? | 2014-06-16 | 2014-06-16 | 0d |
| 4 | Détermination de la date du colloque | 1d? | 2014-06-16 | 2014-06-16 | 0d |
| 5 | Sélection de l'endroit du colloque | 1d? | 2014-06-16 | 2014-06-16 | 0d |
| 6 | Organisation des activités | 1d? | 2014-06-16 | 2014-06-16 | 0d |
| 7 | Détermination du service de traiteur | 1d? | 2014-06-16 | 2014-06-16 | 0d |
| 8 | Organisation des activités sociales | 1d? | 2014-06-16 | 2014-06-16 | 0d |
| 9 | Recherche des conférenciers | 1d? | 2014-06-16 | 2014-06-16 | 0d |
| 10 | Planification de l'horaire du colloque | 1d? | 2014-06-16 | 2014-06-16 | 0d |
| 11 | Rédaction et impression du programme | 1d? | 2014-06-16 | 2014-06-16 | 0d |
| 12 | Relations publiques | 1d? | 2014-06-16 | 2014-06-16 | 0d |
| 13 | Envoi des invitations | 1d? | 2014-06-16 | 2014-06-16 | 0d |
| 14 | Annonce à la communauté scientifique | 1d? | 2014-06-16 | 2014-06-16 | 0d |
| 15 | Suivi des inscriptions | 1d? | 2014-06-16 | 2014-06-16 | 0d |
| 16 | Location du personnel et du matériel | 1d? | 2014-06-16 | 2014-06-16 | 0d |
| 17 | Réservation de l'équipe de nettoyage | 1d? | 2014-06-16 | 2014-06-16 | 0d |
| 18 | Location de l'équipement audiovisuel | 1d? | 2014-06-16 | 2014-06-16 | 0d |
| 19 | Location des tables et des chaises | 1d? | 2014-06-16 | 2014-06-16 | 0d |
| 20 | Préparation du colloque scientifique | 1d? | 2014-06-16 | 2014-06-16 | 0d |
| 21 | Installation de l'équipement | 1d? | 2014-06-16 | 2014-06-16 | 0d |
| 22 | Décoration des salles | 1d? | 2014-06-16 | 2014-06-16 | 0d |
| 23 | Colloque scientifique | 1d? | 2014-06-16 | 2014-06-16 | 0d |
| 24 | Clôture du colloque scientifique | 1d? | 2014-06-16 | 2014-06-16 | 0d |
| 25 | Nettoyage | 1d? | 2014-06-16 | 2014-06-16 | 0d |
| 26 | Paiement des factures | 1d? | 2014-06-16 | 2014-06-16 | 0d |
| 27 | Envoi des lettres de remerciement | 1d? | 2014-06-16 | 2014-06-16 | 0d |
| 28 | Écriture du compte rendu | 1d? | 2014-06-16 | 2014-06-16 | 0d |

## Version 2 (saved 2018-06-12, file Projet3.mpp)

Last finish 2014-06-16 → 2014-06-30 (+14d).

Changed:

| ID | Task | Finish | Duration | Total float |
| --- | --- | --- | --- | --- |
| 3 | Définition du contenu des conférences | 2014-06-16 → 2014-06-18 (+2d) | 1d? → 3d | 0d → 7d |
| 4 | Détermination de la date du colloque | 2014-06-16 → 2014-06-17 (+1d) | 1d? → 2d | 0d → 8d |
| 5 | Sélection de l'endroit du colloque | 2014-06-16 → 2014-06-20 (+4d) | 1d? → 1w | 0d → 5d |
| 7 | Détermination du service de traiteur | 2014-06-16 → 2014-06-17 (+1d) | 1d? → 2d | 0d → 8d |
| 8 | Organisation des activités sociales | 2014-06-16 → 2014-06-20 (+4d) | 1d? → 1w | 0d → 5d |
| 9 | Recherche des conférenciers | 2014-06-16 → 2014-06-30 (+14d) | 1d? → 2w |  |
| 10 | Planification de l'horaire du colloque | 2014-06-16 → 2014-06-17 (+1d) | 1d? → 2d | 0d → 8d |
| 11 | Rédaction et impression du programme | 2014-06-16 → 2014-06-30 (+14d) | 1d? → 2w |  |
| 13 | Envoi des invitations |  | 1d? → 1d | 0d → 9d |
| 14 | Annonce à la communauté scientifique | 2014-06-16 → 2014-06-30 (+14d) | 1d? → 2w |  |
| 15 | Suivi des inscriptions | 2014-06-16 → 2014-06-20 (+4d) | 1d? → 1w | 0d → 5d |
| 17 | Réservation de l'équipe de nettoyage |  | 1d? → 1d | 0d → 9d |
| 18 | Location de l'équipement audiovisuel | 2014-06-16 → 2014-06-18 (+2d) | 1d? → 3d | 0d → 7d |
| 19 | Location des tables et des chaises | 2014-06-16 → 2014-06-17 (+1d) | 1d? → 2d | 0d → 8d |
| 21 | Installation de l'équipement | 2014-06-16 → 2014-06-17 (+1d) | 1d? → 2d | 0d → 8d |
| 22 | Décoration des salles | 2014-06-16 → 2014-06-17 (+1d) | 1d? → 2d | 0d → 8d |
| 23 | Colloque scientifique | 2014-06-16 → 2014-06-18 (+2d) | 1d? → 3d | 0d → 7d |
| 25 | Nettoyage | 2014-06-16 → 2014-06-17 (+1d) | 1d? → 2d | 0d → 8d |
| 26 | Paiement des factures | 2014-06-16 → 2014-06-17 (+1d) | 1d? → 2d | 0d → 8d |
| 27 | Envoi des lettres de remerciement | 2014-06-16 → 2014-06-17 (+1d) | 1d? → 2d | 0d → 8d |
| 28 | Écriture du compte rendu |  | 1d? → 1d | 0d → 9d |

## Version 3 (saved 2018-06-12, file Projet4.mpp)

Last finish stays 2014-06-30.

Changed:

| ID | Task | Finish | Duration | Total float |
| --- | --- | --- | --- | --- |
| 1 | **Planification du colloque scientifique** | 2014-06-16 → 2014-06-30 (+14d) | 1d? → 10d | 9d → 0d |
| 2 | **Réunions initiales de planification** | 2014-06-16 → 2014-06-20 (+4d) | 1d? → 5d | 9d → 5d |
| 6 | **Organisation des activités** | 2014-06-16 → 2014-06-30 (+14d) | 1d? → 10d | 9d → 0d |
| 12 | **Relations publiques** | 2014-06-16 → 2014-06-30 (+14d) | 1d? → 10d | 9d → 0d |
| 16 | **Location du personnel et du matériel** | 2014-06-16 → 2014-06-18 (+2d) | 1d? → 3d | 9d → 7d |
| 20 | **Préparation du colloque scientifique** | 2014-06-16 → 2014-06-18 (+2d) | 1d? → 3d | 9d → 7d |
| 24 | **Clôture du colloque scientifique** | 2014-06-16 → 2014-06-17 (+1d) | 1d? → 2d | 9d → 8d |

## Version 4 (saved 2018-06-12, file Projet6.mpp)

Last finish stays 2014-06-30.

Added:

| ID | Task | Duration | Start | Finish |
| --- | --- | --- | --- | --- |
| 29 | Fin du projet | 0d | 2014-06-16 | 2014-06-16 |

## Version 5 (saved 2018-06-12, file Projet7.mpp)

Last finish 2014-06-30 → 2014-08-26 (+57d).

Added:

| ID | Task | Duration | Start | Finish | Constraint |
| --- | --- | --- | --- | --- | --- |
| 20 | **Réunions, suivi du projet** | 39.25d | 2014-07-02 | 2014-08-26 |  |
| 21 | Réunions, suivi du projet 1 | 2h | 2014-07-02 | 2014-07-02 | start no earlier than 2014-07-01 |
| 22 | Réunions, suivi du projet 2 | 2h | 2014-07-15 | 2014-07-15 | start no earlier than 2014-07-15 |
| 23 | Réunions, suivi du projet 3 | 2h | 2014-07-29 | 2014-07-29 | start no earlier than 2014-07-29 |
| 24 | Réunions, suivi du projet 4 | 2h | 2014-08-12 | 2014-08-12 | start no earlier than 2014-08-12 |
| 25 | Réunions, suivi du projet 5 | 2h | 2014-08-26 | 2014-08-26 | start no earlier than 2014-08-26 |

Changed:

| ID | Task | Finish | Duration |
| --- | --- | --- | --- |
| 1 | **Planification du colloque scientifique** | 2014-06-30 → 2014-08-26 (+57d) | 10d → 49.25d |

## Version 6 (saved 2018-06-12, file Projet8.mpp)

Last finish 2014-08-26 → 2014-10-01 (+36d).

Changed:

| ID | Task | Start | Finish | Duration | Total float | Predecessors |
| --- | --- | --- | --- | --- | --- | --- |
| 1 | **Planification du colloque scientifique** |  | 2014-08-26 → 2014-09-11 (+16d) | 49.25d → 61d |  |  |
| 2 | **Réunions initiales de planification** |  | 2014-06-20 → 2014-06-30 (+10d) | 5d → 10d | 44.25d → 0d |  |
| 4 | Détermination de la date du colloque | 2014-06-16 → 2014-06-19 (+3d) | 2014-06-17 → 2014-06-20 (+3d) |  | 8d → 0d | none → 3 |
| 5 | Sélection de l'endroit du colloque | 2014-06-16 → 2014-06-23 (+7d) | 2014-06-20 → 2014-06-30 (+10d) |  | 5d → 0d | none → 4 |
| 6 | **Organisation des activités** | 2014-06-16 → 2014-07-02 (+16d) | 2014-06-30 → 2014-08-11 (+42d) | 10d → 29d | 39.25d → 0d | none → 5 |
| 7 | Détermination du service de traiteur | 2014-06-16 → 2014-07-02 (+16d) | 2014-06-17 → 2014-07-03 (+16d) |  | 8d → 0d |  |
| 8 | Organisation des activités sociales | 2014-06-16 → 2014-07-04 (+18d) | 2014-06-20 → 2014-07-10 (+20d) |  | 5d → 0d | none → 7 |
| 9 | Recherche des conférenciers | 2014-06-16 → 2014-07-11 (+25d) | 2014-06-30 → 2014-07-24 (+24d) |  | 39.25d → 0d | none → 8 |
| 10 | Planification de l'horaire du colloque | 2014-06-16 → 2014-07-25 (+39d) | 2014-06-17 → 2014-07-28 (+41d) |  | 8d → 0d | none → 9 |
| 11 | Rédaction et impression du programme | 2014-06-16 → 2014-07-29 (+43d) | 2014-06-30 → 2014-08-11 (+42d) |  | 39.25d → 0d | none → 10 |
| 12 | **Relations publiques** | 2014-06-16 → 2014-08-12 (+57d) | 2014-06-30 → 2014-09-03 (+65d) | 10d → 16d | 39.25d → 0d | none → 2, 11 |
| 13 | Envoi des invitations | 2014-06-16 → 2014-08-12 (+57d) | 2014-06-16 → 2014-08-12 (+57d) |  | 9d → 0d |  |
| 14 | Annonce à la communauté scientifique | 2014-06-16 → 2014-08-13 (+58d) | 2014-06-30 → 2014-08-26 (+57d) |  | 39.25d → 0d | none → 13 |
| 15 | Suivi des inscriptions | 2014-06-16 → 2014-08-27 (+72d) | 2014-06-20 → 2014-09-03 (+75d) |  | 5d → 0d | none → 14 |
| 16 | **Location du personnel et du matériel** | 2014-06-16 → 2014-09-04 (+80d) | 2014-06-18 → 2014-09-11 (+85d) | 3d → 6d | 46.25d → 0d | none → 12 |
| 17 | Réservation de l'équipe de nettoyage | 2014-06-16 → 2014-09-04 (+80d) | 2014-06-16 → 2014-09-04 (+80d) |  | 9d → 0d |  |
| 18 | Location de l'équipement audiovisuel | 2014-06-16 → 2014-09-05 (+81d) | 2014-06-18 → 2014-09-09 (+83d) |  | 7d → 0d | none → 17 |
| 19 | Location des tables et des chaises | 2014-06-16 → 2014-09-10 (+86d) | 2014-06-17 → 2014-09-11 (+86d) |  | 8d → 0d | none → 18 |
| 26 | **Préparation du colloque scientifique** | 2014-06-16 → 2014-09-12 (+88d) | 2014-06-18 → 2014-09-22 (+96d) | 3d → 7d | 46.25d → 0d | none → 1 |
| 27 | Installation de l'équipement | 2014-06-16 → 2014-09-12 (+88d) | 2014-06-17 → 2014-09-15 (+90d) |  | 47.25d → 0d |  |
| 28 | Décoration des salles | 2014-06-16 → 2014-09-16 (+92d) | 2014-06-17 → 2014-09-17 (+92d) |  | 47.25d → 0d | none → 27 |
| 29 | Colloque scientifique | 2014-06-16 → 2014-09-18 (+94d) | 2014-06-18 → 2014-09-22 (+96d) |  | 46.25d → 0d | none → 28 |
| 30 | **Clôture du colloque scientifique** | 2014-06-16 → 2014-09-23 (+99d) | 2014-06-17 → 2014-10-01 (+106d) | 2d → 7d | 47.25d → 0d | none → 26 |
| 31 | Nettoyage | 2014-06-16 → 2014-09-23 (+99d) | 2014-06-17 → 2014-09-24 (+99d) |  | 47.25d → 0d |  |
| 32 | Paiement des factures | 2014-06-16 → 2014-09-25 (+101d) | 2014-06-17 → 2014-09-26 (+101d) |  | 47.25d → 0d | none → 31 |
| 33 | Envoi des lettres de remerciement | 2014-06-16 → 2014-09-29 (+105d) | 2014-06-17 → 2014-09-30 (+105d) |  | 47.25d → 0d | none → 32 |
| 34 | Écriture du compte rendu | 2014-06-16 → 2014-10-01 (+107d) | 2014-06-16 → 2014-10-01 (+107d) |  | 48.25d → 0d | none → 33 |
| 35 | Fin du projet | 2014-06-16 → 2014-10-01 (+107d) | 2014-06-16 → 2014-10-01 (+107d) |  | 49.25d → 0d | none → 34 |

## Version 7 (saved 2018-06-12, file Projet9.mpp)

Last finish 2014-10-01 → 2014-09-16 (-15d).

Changed:

| ID | Task | Start | Finish | Duration | Total float | Predecessors |
| --- | --- | --- | --- | --- | --- | --- |
| 1 | **Planification du colloque scientifique** |  | 2014-09-11 → 2014-08-26 (-16d) | 61d → 49.25d |  |  |
| 6 | **Organisation des activités** |  | 2014-08-11 → 2014-07-31 (-11d) | 29d → 22d | 0d → 1.25d |  |
| 8 | Organisation des activités sociales | 2014-07-04 → 2014-07-02 (-2d) | 2014-07-10 → 2014-07-08 (-2d) |  | 0d → 1.25d | 7 → 7SS |
| 9 | Recherche des conférenciers | 2014-07-11 → 2014-07-02 (-9d) | 2014-07-24 → 2014-07-15 (-9d) |  | 0d → 1.25d | 8 → 8SS |
| 10 | Planification de l'horaire du colloque | 2014-07-25 → 2014-07-16 (-9d) | 2014-07-28 → 2014-07-17 (-11d) |  | 0d → 1.25d |  |
| 11 | Rédaction et impression du programme | 2014-07-29 → 2014-07-18 (-11d) | 2014-08-11 → 2014-07-31 (-11d) |  | 0d → 1.25d |  |
| 12 | **Relations publiques** | 2014-08-12 → 2014-08-01 (-11d) | 2014-09-03 → 2014-08-22 (-12d) |  | 0d → 1.25d |  |
| 13 | Envoi des invitations | 2014-08-12 → 2014-08-01 (-11d) | 2014-08-12 → 2014-08-01 (-11d) |  | 0d → 1.25d |  |
| 14 | Annonce à la communauté scientifique | 2014-08-13 → 2014-08-04 (-9d) | 2014-08-26 → 2014-08-15 (-11d) |  | 0d → 1.25d |  |
| 15 | Suivi des inscriptions | 2014-08-27 → 2014-08-18 (-9d) | 2014-09-03 → 2014-08-22 (-12d) |  | 0d → 1.25d |  |
| 16 | **Location du personnel et du matériel** | 2014-09-04 → 2014-08-01 (-34d) | 2014-09-11 → 2014-08-08 (-34d) |  | 0d → 11.25d | 12 → 12SS |
| 17 | Réservation de l'équipe de nettoyage | 2014-09-04 → 2014-08-01 (-34d) | 2014-09-04 → 2014-08-01 (-34d) |  | 0d → 11.25d |  |
| 18 | Location de l'équipement audiovisuel | 2014-09-05 → 2014-08-04 (-32d) | 2014-09-09 → 2014-08-06 (-34d) |  | 0d → 11.25d |  |
| 19 | Location des tables et des chaises | 2014-09-10 → 2014-08-07 (-34d) | 2014-09-11 → 2014-08-08 (-34d) |  | 0d → 11.25d |  |
| 26 | **Préparation du colloque scientifique** | 2014-09-12 → 2014-08-26 (-17d) | 2014-09-22 → 2014-09-05 (-17d) |  |  |  |
| 27 | Installation de l'équipement | 2014-09-12 → 2014-08-26 (-17d) | 2014-09-15 → 2014-08-28 (-18d) |  |  |  |
| 28 | Décoration des salles | 2014-09-16 → 2014-08-28 (-19d) | 2014-09-17 → 2014-09-02 (-15d) |  |  |  |
| 29 | Colloque scientifique | 2014-09-18 → 2014-09-02 (-16d) | 2014-09-22 → 2014-09-05 (-17d) |  |  |  |
| 30 | **Clôture du colloque scientifique** | 2014-09-23 → 2014-09-05 (-18d) | 2014-10-01 → 2014-09-16 (-15d) |  |  |  |
| 31 | Nettoyage | 2014-09-23 → 2014-09-05 (-18d) | 2014-09-24 → 2014-09-09 (-15d) |  |  |  |
| 32 | Paiement des factures | 2014-09-25 → 2014-09-09 (-16d) | 2014-09-26 → 2014-09-11 (-15d) |  |  |  |
| 33 | Envoi des lettres de remerciement | 2014-09-29 → 2014-09-11 (-18d) | 2014-09-30 → 2014-09-15 (-15d) |  |  |  |
| 34 | Écriture du compte rendu | 2014-10-01 → 2014-09-15 (-16d) | 2014-10-01 → 2014-09-16 (-15d) |  |  |  |
| 35 | Fin du projet | 2014-10-01 → 2014-09-16 (-15d) | 2014-10-01 → 2014-09-16 (-15d) |  |  |  |

## Version 8 (saved 2018-06-12, file Projet10.mpp)

Last finish stays 2014-09-16.

Changed:

| ID | Task | Start | Finish | Duration | Total float | Predecessors |
| --- | --- | --- | --- | --- | --- | --- |
| 6 | **Organisation des activités** |  | 2014-07-31 → 2014-08-01 (+1d) | 22d → 22.5d | 1.25d → 0.25d | 5 → 5FS+2h |
| 7 | Détermination du service de traiteur |  | 2014-07-03 → 2014-07-04 (+1d) |  | 1.25d → 1d |  |
| 8 | Organisation des activités sociales |  | 2014-07-08 → 2014-07-09 (+1d) |  | 1.25d → 1d |  |
| 9 | Recherche des conférenciers |  | 2014-07-15 → 2014-07-16 (+1d) |  | 1.25d → 0.75d |  |
| 10 | Planification de l'horaire du colloque |  | 2014-07-17 → 2014-07-18 (+1d) |  | 1.25d → 0.75d |  |
| 11 | Rédaction et impression du programme |  | 2014-07-31 → 2014-08-01 (+1d) |  | 1.25d → 0.5d |  |
| 12 | **Relations publiques** |  | 2014-08-22 → 2014-08-25 (+3d) | 16d → 16.25d | 1.25d → 0.25d |  |
| 13 | Envoi des invitations |  | 2014-08-01 → 2014-08-04 (+3d) |  | 1.25d → 0.25d |  |
| 14 | Annonce à la communauté scientifique |  | 2014-08-15 → 2014-08-18 (+3d) |  | 1.25d → 0.25d |  |
| 15 | Suivi des inscriptions | 2014-08-18 → 2014-08-19 (+1d) | 2014-08-22 → 2014-08-25 (+3d) |  | 1.25d → 0.25d |  |
| 16 | **Location du personnel et du matériel** |  | 2014-08-08 → 2014-08-11 (+3d) |  | 11.25d → 10.5d |  |
| 17 | Réservation de l'équipe de nettoyage |  | 2014-08-01 → 2014-08-04 (+3d) |  | 11.25d → 10.5d |  |
| 18 | Location de l'équipement audiovisuel |  | 2014-08-06 → 2014-08-07 (+1d) |  | 11.25d → 10.5d |  |
| 19 | Location des tables et des chaises |  | 2014-08-08 → 2014-08-11 (+3d) |  | 11.25d → 10.5d |  |

## Version 9 (saved 2018-06-12, file Projet11.mpp)

Last finish stays 2014-09-16.

Changed:

| ID | Task | Start | Duration | Other |
| --- | --- | --- | --- | --- |
| 26 | **Préparation du colloque scientifique** |  | 7d → 7.75d |  |
| 29 | Colloque scientifique | 2014-09-02 → 2014-09-03 (+1d) |  | constraint none → must start on 2014-09-03 |
| 30 | **Clôture du colloque scientifique** | 2014-09-05 → 2014-09-08 (+3d) |  |  |
| 31 | Nettoyage | 2014-09-05 → 2014-09-08 (+3d) |  |  |
| 32 | Paiement des factures | 2014-09-09 → 2014-09-10 (+1d) |  |  |
| 33 | Envoi des lettres de remerciement | 2014-09-11 → 2014-09-12 (+1d) |  |  |
| 34 | Écriture du compte rendu | 2014-09-15 → 2014-09-16 (+1d) |  |  |

## Version 10 (saved 2018-06-12, file Projet14.mpp)

Last finish 2014-09-16 → 2014-09-12 (-4d).

Changed:

| ID | Task | Start | Finish | Duration | Total float | Other |
| --- | --- | --- | --- | --- | --- | --- |
| 3 | Définition du contenu des conférences |  |  |  |  | resources none → Jean Fillion; Lucie Dorval; Marie Plourde; Pierre Legrand |
| 4 | Détermination de la date du colloque |  |  |  |  | resources none → Jean Fillion; Lucie Dorval; Marie Plourde; Pierre Legrand |
| 5 | Sélection de l'endroit du colloque |  |  |  |  | resources none → Jean Fillion; Lucie Dorval; Marie Plourde; Pierre Legrand |
| 7 | Détermination du service de traiteur |  |  |  |  | resources none → Marie Plourde |
| 8 | Organisation des activités sociales |  |  |  |  | resources none → Marie Plourde |
| 9 | Recherche des conférenciers |  |  |  |  | resources none → Jean Fillion |
| 10 | Planification de l'horaire du colloque |  |  |  |  | resources none → Jean Fillion |
| 11 | Rédaction et impression du programme |  |  |  |  | resources none → Sophie Martin; Thomas Dupuis; Imprimeur |
| 13 | Envoi des invitations |  |  |  | 0.25d → 1d | resources none → Sophie Martin |
| 14 | Annonce à la communauté scientifique |  |  |  | 0.25d → 1d | resources none → Thomas Dupuis; Pierre Legrand |
| 15 | Suivi des inscriptions |  |  |  |  | resources none → Sophie Martin |
| 16 | **Location du personnel et du matériel** |  | 2014-08-11 → 2014-08-25 (+14d) | 6d → 16d | 11.25d → 1.25d |  |
| 17 | Réservation de l'équipe de nettoyage |  | 2014-08-04 → 2014-08-18 (+14d) |  | 10.5d → 1.25d | resources none → Lucie Dorval |
| 18 | Location de l'équipement audiovisuel | 2014-08-04 → 2014-08-18 (+14d) | 2014-08-07 → 2014-08-21 (+14d) |  | 10.5d → 1.25d | resources none → Lucie Dorval |
| 19 | Location des tables et des chaises | 2014-08-07 → 2014-08-21 (+14d) | 2014-08-11 → 2014-08-25 (+14d) |  | 10.5d → 1.25d | resources none → Lucie Dorval |
| 21 | Réunions, suivi du projet 1 |  |  |  | 39d → 39.75d | resources none → Déjeuner [0.1%]; Jean Fillion; Marie Plourde; Pierre Legrand; Sophie Martin; Thomas Dupuis |
| 22 | Réunions, suivi du projet 2 |  |  |  | 30d → 30.75d | resources none → Déjeuner [0.1%]; Jean Fillion; Marie Plourde; Pierre Legrand; Sophie Martin; Thomas Dupuis; Lucie Dorval |
| 23 | Réunions, suivi du projet 3 |  |  |  | 20d → 20.75d | resources none → Déjeuner [0.1%]; Jean Fillion; Marie Plourde; Pierre Legrand; Sophie Martin; Thomas Dupuis; Lucie Dorval |
| 24 | Réunions, suivi du projet 4 |  |  |  | 10d → 10.75d | resources none → Déjeuner [0.1%]; Jean Fillion; Marie Plourde; Pierre Legrand; Sophie Martin; Thomas Dupuis |
| 25 | Réunions, suivi du projet 5 |  |  |  |  | resources none → Déjeuner [0.1%]; Jean Fillion; Marie Plourde; Pierre Legrand; Sophie Martin; Thomas Dupuis; Lucie Dorval |
| 27 | Installation de l'équipement |  |  |  |  | resources none → Lucie Dorval |
| 28 | Décoration des salles |  |  |  |  | resources none → Lucie Dorval |
| 29 | Colloque scientifique |  |  |  |  | resources none → Marie Plourde; Pierre Legrand; Équipement audiovisuel; Chaises [1000 Unité]; Tables [100 Tb de 10 prs] |
| 30 | **Clôture du colloque scientifique** | 2014-09-08 → 2014-09-06 (-2d) | 2014-09-16 → 2014-09-12 (-4d) | 7d → 5d |  |  |
| 31 | Nettoyage | 2014-09-08 → 2014-09-06 (-2d) | 2014-09-09 → 2014-09-07 (-2d) |  |  | resources none → Équipe de nettoyage [300%] |
| 32 | Paiement des factures | 2014-09-10 → 2014-09-08 (-2d) | 2014-09-11 → 2014-09-09 (-2d) |  |  | resources none → Pierre Legrand; Éric Martel |
| 33 | Envoi des lettres de remerciement | 2014-09-12 → 2014-09-10 (-2d) | 2014-09-15 → 2014-09-11 (-4d) |  |  | resources none → Pierre Legrand |
| 34 | Écriture du compte rendu | 2014-09-16 → 2014-09-12 (-4d) | 2014-09-16 → 2014-09-12 (-4d) |  |  | resources none → Pierre Legrand |
| 35 | Fin du projet | 2014-09-16 → 2014-09-12 (-4d) | 2014-09-16 → 2014-09-12 (-4d) |  |  |  |

## Version 11 (saved 2018-06-12, file Projet15.mpp)

Last finish stays 2014-09-12.

Changed:

| ID | Task | Start | Finish | Total float | Predecessors |
| --- | --- | --- | --- | --- | --- |
| 8 | Organisation des activités sociales | 2014-07-02 → 2014-07-04 (+2d) | 2014-07-09 → 2014-07-11 (+2d) | 0d → 32.75d | 7SS → 7SS+2d |
| 9 | Recherche des conférenciers |  |  |  | 8SS → 7SS |

## Version 12 (saved 2018-06-12, file Projet19.mpp)

Last finish stays 2014-09-12.

Changed:

| ID | Task | Other |
| --- | --- | --- |
| 11 | Rédaction et impression du programme | resources Sophie Martin; Thomas Dupuis; Imprimeur → Sophie Martin; Thomas Dupuis; PrintExpress |

## Version 13 (saved 2018-06-12, file Projet20.mpp)

Last finish stays 2014-09-12.

Changed:

| ID | Task | Other |
| --- | --- | --- |
| 1 | **Planification du colloque scientifique** | baseline start none → 2014-06-16; baseline finish none → 2014-08-26 |
| 2 | **Réunions initiales de planification** | baseline start none → 2014-06-16; baseline finish none → 2014-06-30 |
| 3 | Définition du contenu des conférences | baseline start none → 2014-06-16; baseline finish none → 2014-06-18 |
| 4 | Détermination de la date du colloque | baseline start none → 2014-06-19; baseline finish none → 2014-06-20 |
| 5 | Sélection de l'endroit du colloque | baseline start none → 2014-06-23; baseline finish none → 2014-06-30 |
| 6 | **Organisation des activités** | baseline start none → 2014-07-02; baseline finish none → 2014-08-01 |
| 7 | Détermination du service de traiteur | baseline start none → 2014-07-02; baseline finish none → 2014-07-04 |
| 8 | Organisation des activités sociales | baseline start none → 2014-07-04; baseline finish none → 2014-07-11 |
| 9 | Recherche des conférenciers | baseline start none → 2014-07-02; baseline finish none → 2014-07-16 |
| 10 | Planification de l'horaire du colloque | baseline start none → 2014-07-16; baseline finish none → 2014-07-18 |
| 11 | Rédaction et impression du programme | baseline start none → 2014-07-18; baseline finish none → 2014-08-01 |
| 12 | **Relations publiques** | baseline start none → 2014-08-01; baseline finish none → 2014-08-25 |
| 13 | Envoi des invitations | baseline start none → 2014-08-01; baseline finish none → 2014-08-04 |
| 14 | Annonce à la communauté scientifique | baseline start none → 2014-08-04; baseline finish none → 2014-08-18 |
| 15 | Suivi des inscriptions | baseline start none → 2014-08-19; baseline finish none → 2014-08-25 |
| 16 | **Location du personnel et du matériel** | baseline start none → 2014-08-01; baseline finish none → 2014-08-25 |
| 17 | Réservation de l'équipe de nettoyage | baseline start none → 2014-08-01; baseline finish none → 2014-08-18 |
| 18 | Location de l'équipement audiovisuel | baseline start none → 2014-08-18; baseline finish none → 2014-08-21 |
| 19 | Location des tables et des chaises | baseline start none → 2014-08-21; baseline finish none → 2014-08-25 |
| 20 | **Réunions, suivi du projet** | baseline start none → 2014-07-02; baseline finish none → 2014-08-26 |
| 21 | Réunions, suivi du projet 1 | baseline start none → 2014-07-02; baseline finish none → 2014-07-02 |
| 22 | Réunions, suivi du projet 2 | baseline start none → 2014-07-15; baseline finish none → 2014-07-15 |
| 23 | Réunions, suivi du projet 3 | baseline start none → 2014-07-29; baseline finish none → 2014-07-29 |
| 24 | Réunions, suivi du projet 4 | baseline start none → 2014-08-12; baseline finish none → 2014-08-12 |
| 25 | Réunions, suivi du projet 5 | baseline start none → 2014-08-26; baseline finish none → 2014-08-26 |
| 26 | **Préparation du colloque scientifique** | baseline start none → 2014-08-26; baseline finish none → 2014-09-05 |
| 27 | Installation de l'équipement | baseline start none → 2014-08-26; baseline finish none → 2014-08-28 |
| 28 | Décoration des salles | baseline start none → 2014-08-28; baseline finish none → 2014-09-02 |
| 29 | Colloque scientifique | baseline start none → 2014-09-03; baseline finish none → 2014-09-05 |
| 30 | **Clôture du colloque scientifique** | baseline start none → 2014-09-06; baseline finish none → 2014-09-12 |
| 31 | Nettoyage | baseline start none → 2014-09-06; baseline finish none → 2014-09-07 |
| 32 | Paiement des factures | baseline start none → 2014-09-08; baseline finish none → 2014-09-09 |
| 33 | Envoi des lettres de remerciement | baseline start none → 2014-09-10; baseline finish none → 2014-09-11 |
| 34 | Écriture du compte rendu | baseline start none → 2014-09-12; baseline finish none → 2014-09-12 |
| 35 | Fin du projet | baseline start none → 2014-09-12; baseline finish none → 2014-09-12 |

## Version 14 (data date 2014-07-04, saved 2018-06-12, file Projet21.mpp)

Last finish stays 2014-09-12. Complete tasks 0 → 4.

Changed:

| ID | Task | Start | Finish | Complete | Total float |
| --- | --- | --- | --- | --- | --- |
| 1 | **Planification du colloque scientifique** | 2014-06-16 A |  | 0% → 25% | 0d → 0.75d |
| 2 | **Réunions initiales de planification** | 2014-06-16 A | 2014-06-30 A | 0% → 100% | 0d → none |
| 3 | Définition du contenu des conférences | 2014-06-16 A | 2014-06-18 A | 0% → 100% | 0d → none |
| 4 | Détermination de la date du colloque | 2014-06-19 A | 2014-06-20 A | 0% → 100% | 0d → none |
| 5 | Sélection de l'endroit du colloque | 2014-06-23 A | 2014-06-30 A | 0% → 100% | 0d → none |
| 6 | **Organisation des activités** | 2014-07-02 A |  | 0% → 19% | 0d → 17.25d |
| 7 | Détermination du service de traiteur | 2014-07-02 A | 2014-07-04 A | 0% → 100% | 0d → none |
| 8 | Organisation des activités sociales | 2014-07-04 A |  | 0% → 15% |  |
| 9 | Recherche des conférenciers | 2014-07-02 A |  | 0% → 28% |  |
| 20 | **Réunions, suivi du projet** | 2014-07-02 A |  | 0% → 20% |  |
| 21 | Réunions, suivi du projet 1 | 2014-07-02 A |  | 0% → 99% |  |

## Version 15 (data date 2014-07-18, saved 2018-06-12, file Projet23.mpp)

Last finish stays 2014-09-12. Complete tasks 4 → 6.

Changed:

| ID | Task | Start | Finish | Duration | Complete | Total float |
| --- | --- | --- | --- | --- | --- | --- |
| 1 | **Planification du colloque scientifique** |  | 2014-08-26 → 2014-08-27 (+1d) | 49.25d → 51d | 25% → 44% | 0.75d → -1d |
| 6 | **Organisation des activités** |  | 2014-08-01 → 2014-08-05 (+4d) | 22.5d → 24.5d | 19% → 59% | 17.25d → -1d |
| 8 | Organisation des activités sociales |  | 2014-07-11 → 2014-07-09 A (-2d) | 1w → 0.6w | 15% → 100% | 32.75d → none |
| 9 | Recherche des conférenciers |  | 2014-07-16 A |  | 28% → 100% | 0d → none |
| 10 | Planification de l'horaire du colloque | 2014-07-16 A | 2014-07-18 → 2014-07-22 (+4d) | 2d → 4d | 0% → 50% | 0d → -2d |
| 11 | Rédaction et impression du programme | 2014-07-18 → 2014-07-22 (+4d) | 2014-08-01 → 2014-08-05 (+4d) |  |  | 1d → -1d |
| 12 | **Relations publiques** | 2014-08-01 → 2014-08-05 (+4d) | 2014-08-25 → 2014-08-27 (+2d) |  |  | 1d → -1d |
| 13 | Envoi des invitations | 2014-08-01 → 2014-08-05 (+4d) | 2014-08-04 → 2014-08-06 (+2d) |  |  | 1d → -1d |
| 14 | Annonce à la communauté scientifique | 2014-08-04 → 2014-08-06 (+2d) | 2014-08-18 → 2014-08-20 (+2d) |  |  | 1d → -1d |
| 15 | Suivi des inscriptions | 2014-08-19 → 2014-08-21 (+2d) | 2014-08-25 → 2014-08-27 (+2d) |  |  | 1d → -1d |
| 16 | **Location du personnel et du matériel** | 2014-08-01 → 2014-08-18 (+17d) |  | 16d → 6d |  | 1.25d → 1d |
| 17 | Réservation de l'équipe de nettoyage | 2014-08-01 → 2014-08-18 (+17d) |  |  |  | 1.25d → 1d |
| 18 | Location de l'équipement audiovisuel | 2014-08-18 → 2014-08-19 (+1d) |  |  |  | 1.25d → 1d |
| 19 | Location des tables et des chaises | 2014-08-21 → 2014-08-22 (+1d) |  |  |  | 1.25d → 1d |
| 26 | **Préparation du colloque scientifique** | 2014-08-26 → 2014-08-28 (+2d) |  | 7.75d → 6d |  | 0d → -1d |
| 27 | Installation de l'équipement | 2014-08-26 → 2014-08-28 (+2d) | 2014-08-28 → 2014-08-29 (+1d) |  |  | 0.75d → -1d |
| 28 | Décoration des salles | 2014-08-28 → 2014-09-02 (+5d) | 2014-09-02 → 2014-09-03 (+1d) |  |  | 0.75d → -1d |
